# План-график общий по проекту

Schedule from MS Project, 2015-09-07 to 2016-05-06.
SPecialiST RePack

## Calendars

- Стандартный: Mon-Fri 09:00-13:00, 14:00-18:00; Sat-Sun off.

## Resources

| Resource |
| --- |
| Программист |
| Постановщик |
| Аналитик |
| Дизайнер проектов |
| Руководитель проектов |
| Внедренец |

## Schedule

| ID | Task | Type | Duration | Start | Finish | Resources | Work |
| --- | --- | --- | --- | --- | --- | --- | --- |
| 1 | Подготовка и презентация решения КАРАБИ заказчику. | manual | 5d | 2015-09-07 | 2015-09-11 | Аналитик | 40h |
| 2 | Разработка технического задания | manual | 15d | 2015-09-14 | 2015-10-02 | Аналитик | 120h |
| 3 | Установка БД и системы КАРАБИ. Первичная настройка оргштатной структуры и создание пользователей | manual | 1d | 2015-10-05 | 2015-10-05 | Внедренец | 8h |
| 4 | Второй этап выполнения работ . «Прием заявок, автоматизация предконтрактной работы, учет выполнения работ» | manual | 50d | 2015-10-12 | 2015-12-18 | Аналитик; Внедренец; Постановщик; Программист; Руководитель проектов | 2000h |
| 5 | Третий этап выполнения работ «Процесс управления закупками» | manual | 20d | 2015-12-21 | 2016-01-15 | Аналитик; Внедренец; Постановщик; Программист; Руководитель проектов | 800h |
| 6 | Четвертый этап выполнения работ «Процесс управления работами» | manual | 35d | 2016-01-18 | 2016-03-04 | Аналитик; Внедренец; Дизайнер проектов; Постановщик; Программист; Руководитель проектов | 1680h |
| 7 | Пятый этап выполнения работ «Транспортная деятельность, складской учет» | manual | 25d | 2016-03-07 | 2016-04-08 |  |  |
| 8 | Шестой этап выполнения работ «Кадры и финансы» | manual | 10d | 2016-04-11 | 2016-04-22 | Аналитик; Внедренец; Постановщик; Программист; Руководитель проектов | 400h |
| 9 | Седьмой этап выполнения работ «Автоматизация тендерных заявок» | manual | 10d | 2016-04-25 | 2016-05-06 | Аналитик; Внедренец; Постановщик; Программист; Руководитель проектов | 400h |
